# 2008 Annual Report

How a schedule from MS Project changed from version to version. A marks actual dates.

## Version 1 (data date 2013-02-28, saved 2013-09-16, file 7macro.mpp)

| ID | WBS | Task | Duration | Start | Finish | Predecessors | Complete | Total float | Constraint |
| --- | --- | --- | --- | --- | --- | --- | --- | --- | --- |
| 1 | 1 | **Annual Financial Report** | 39.38d | 2013-01-04 A | 2013-02-28 |  | 44% | 0d |  |
| 2 | 1.1 | **Initial Planning** | 3d | 2013-01-04 A | 2013-01-08 A |  | 100% |  |  |
| 3 |  | Outline report articles | 3d | 2013-01-04 A | 2013-01-08 A |  | 100% |  |  |
| 4 | 1.2 | **Interview Management** | 3.5d | 2013-01-07 A | 2013-01-10 A |  | 100% |  |  |
| 5 |  | President | 0.5d | 2013-01-07 A | 2013-01-07 A | 3 | 100% |  |  |
| 6 |  | Vice President | 0.5d | 2013-01-07 A | 2013-01-07 A | 5 | 100% |  |  |
| 7 |  | Marketing VP | 0.5d | 2013-01-10 A | 2013-01-10 A | 6 | 100% |  |  |
| 8 |  | Chief Financial Officer | 0.5d | 2013-01-08 A | 2013-01-08 A | 7 | 100% |  |  |
| 9 | 1.3 | **Assemble Financial Reports** | 13d | 2013-01-07 A | 2013-01-24 |  | 94% | 25.38d |  |
| 10 |  | Gather financial data | 3.38d | 2013-01-07 A | 2013-01-10 A | 3 | 100% |  |  |
| 11 |  | Format reports | 2d | 2013-01-08 A | 2013-01-09 A | 10FS-2d | 100% |  |  |
| 12 |  | Compile data reference report | 1d | 2013-01-14 A | 2013-01-14 A | 11 | 100% |  |  |
| 13 |  | Create graphics and charts | 3.12d | 2013-01-14 A | 2013-01-16 A | 12SS | 100% |  |  |
| 14 |  | Review by CFO | 5d | 2013-01-14 A | 2013-01-18 A | 13 | 100% |  |  |
| 15 |  | Edit | 2d | 2013-01-21 A | 2013-01-22 | 14 | 50% | 26.38d |  |
| 16 |  | Final approval | 0d | 2013-01-24 | 2013-01-24 |  |  | 0d | start no earlier than 2013-01-24 |
| 17 | 1.4 | **Write Articles** | 10d | 2013-01-24 | 2013-02-06 |  |  | 0d |  |
| 18 |  | Write first draft | 3d | 2013-01-24 | 2013-01-28 | 16 |  | 0d |  |
| 19 |  | Management review | 5d | 2013-01-29 | 2013-02-04 | 18 |  | 0d | as late as possible |
| 20 |  | Edit | 3d | 2013-02-04 | 2013-02-06 | 19FS-1d |  | 0d |  |
| 21 |  | Final text approval | 0d | 2013-02-06 | 2013-02-06 | 20 |  | 0d |  |
| 22 | 1.5 | **Prepare Final Materials** | 8.5d | 2013-02-07 | 2013-02-19 |  |  | 0d |  |
| 23 |  | Final layout | 3d | 2013-02-07 | 2013-02-11 | 21 |  | 0d |  |
| 24 |  | Final proof | 3d | 2013-02-12 | 2013-02-14 | 23 |  | 0d |  |
| 25 |  | Copy reports | 2.5d | 2013-02-15 | 2013-02-19 | 24 |  | 0d |  |
| 26 |  | Write cover letter | 2d | 2013-02-15 | 2013-02-19 | 25FF |  | 0d |  |
| 27 | 1.6 | **Distribute Reports** | 6.88d | 2013-02-19 | 2013-02-28 |  |  | 0d |  |
| 28 |  | Order envelopes/paper stock | 1d | 2013-02-19 | 2013-02-20 | 26 |  | 0d |  |
| 29 |  | Print cover letters/envelopes | 2d | 2013-02-25 | 2013-02-27 | 28FS+3d |  | 0d |  |
| 30 |  | Stuff report packets | 1d | 2013-02-27 | 2013-02-28 | 29 |  | 0d |  |
| 31 |  | Report packets sent | 0d | 2013-02-28 | 2013-02-28 | 30 |  | 0d | as late as possible |

## Version 2 (data date 2013-09-26, saved 2013-08-31, file 1report.mpp)

Last finish 2013-02-28 → 2013-09-26 (+210d).

Changed:

| ID | Task | Start | Finish | Other |
| --- | --- | --- | --- | --- |
| 1 | **Annual Financial Report** | 2013-01-04 A → 2013-08-02 A (+210d) | 2013-02-28 → 2013-09-26 (+210d) | baseline start 2013-01-04 → none; baseline finish 2013-02-28 → none |
| 2 | **Initial Planning** | 2013-01-04 A → 2013-08-02 A (+210d) | 2013-01-08 A → 2013-08-06 A (+210d) | baseline start 2013-01-04 → none; baseline finish 2013-01-08 → none |
| 3 | Outline report articles | 2013-01-04 A → 2013-08-02 A (+210d) | 2013-01-08 A → 2013-08-06 A (+210d) | baseline start 2013-01-04 → none; baseline finish 2013-01-08 → none |
| 4 | **Interview Management** | 2013-01-07 A → 2013-08-05 A (+210d) | 2013-01-10 A → 2013-08-08 A (+210d) | baseline start 2013-01-07 → none; baseline finish 2013-01-10 → none |
| 5 | President | 2013-01-07 A → 2013-08-05 A (+210d) | 2013-01-07 A → 2013-08-05 A (+210d) | baseline start 2013-01-07 → none; baseline finish 2013-01-07 → none |
| 6 | Vice President | 2013-01-07 A → 2013-08-05 A (+210d) | 2013-01-07 A → 2013-08-05 A (+210d) | baseline start 2013-01-07 → none; baseline finish 2013-01-07 → none |
| 7 | Marketing VP | 2013-01-10 A → 2013-08-08 A (+210d) | 2013-01-10 A → 2013-08-08 A (+210d) | baseline start 2013-01-10 → none; baseline finish 2013-01-10 → none |
| 8 | Chief Financial Officer | 2013-01-08 A → 2013-08-06 A (+210d) | 2013-01-08 A → 2013-08-06 A (+210d) | baseline start 2013-01-08 → none; baseline finish 2013-01-08 → none |
| 9 | **Assemble Financial Reports** | 2013-01-07 A → 2013-08-05 A (+210d) | 2013-01-24 → 2013-08-22 (+210d) | baseline start 2013-01-07 → none; baseline finish 2013-01-24 → none |
| 10 | Gather financial data | 2013-01-07 A → 2013-08-05 A (+210d) | 2013-01-10 A → 2013-08-08 A (+210d) | baseline start 2013-01-07 → none; baseline finish 2013-01-10 → none |
| 11 | Format reports | 2013-01-08 A → 2013-08-06 A (+210d) | 2013-01-09 A → 2013-08-07 A (+210d) | baseline start 2013-01-08 → none; baseline finish 2013-01-09 → none |
| 12 | Compile data reference report | 2013-01-14 A → 2013-08-12 A (+210d) | 2013-01-14 A → 2013-08-12 A (+210d) | baseline start 2013-01-14 → none; baseline finish 2013-01-14 → none |
| 13 | Create graphics and charts | 2013-01-14 A → 2013-08-12 A (+210d) | 2013-01-16 A → 2013-08-14 A (+210d) | baseline start 2013-01-14 → none; baseline finish 2013-01-16 → none |
| 14 | Review by CFO | 2013-01-14 A → 2013-08-12 A (+210d) | 2013-01-18 A → 2013-08-16 A (+210d) | baseline start 2013-01-14 → none; baseline finish 2013-01-18 → none |
| 15 | Edit | 2013-01-21 A → 2013-08-19 A (+210d) | 2013-01-22 → 2013-08-20 (+210d) | baseline start 2013-01-21 → none; baseline finish 2013-01-22 → none |
| 16 | Final approval | 2013-01-24 → 2013-08-22 (+210d) | 2013-01-24 → 2013-08-22 (+210d) | constraint start no earlier than 2013-01-24 → start no earlier than 2013-08-22; baseline start 2013-01-24 → none; baseline finish 2013-01-24 → none |
| 17 | **Write Articles** | 2013-01-24 → 2013-08-22 (+210d) | 2013-02-06 → 2013-09-04 (+210d) | baseline start 2013-01-24 → none; baseline finish 2013-02-06 → none |
| 18 | Write first draft | 2013-01-24 → 2013-08-22 (+210d) | 2013-01-28 → 2013-08-26 (+210d) | baseline start 2013-01-24 → none; baseline finish 2013-01-28 → none |
| 19 | Management review | 2013-01-29 → 2013-08-27 (+210d) | 2013-02-04 → 2013-09-02 (+210d) | baseline start 2013-01-29 → none; baseline finish 2013-02-04 → none |
| 20 | Edit | 2013-02-04 → 2013-09-02 (+210d) | 2013-02-06 → 2013-09-04 (+210d) | baseline start 2013-02-04 → none; baseline finish 2013-02-06 → none |
| 21 | Final text approval | 2013-02-06 → 2013-09-04 (+210d) | 2013-02-06 → 2013-09-04 (+210d) | baseline start 2013-02-06 → none; baseline finish 2013-02-06 → none |
| 22 | **Prepare Final Materials** | 2013-02-07 → 2013-09-05 (+210d) | 2013-02-19 → 2013-09-17 (+210d) | baseline start 2013-02-07 → none; baseline finish 2013-02-19 → none |
| 23 | Final layout | 2013-02-07 → 2013-09-05 (+210d) | 2013-02-11 → 2013-09-09 (+210d) | baseline start 2013-02-07 → none; baseline finish 2013-02-11 → none |
| 24 | Final proof | 2013-02-12 → 2013-09-10 (+210d) | 2013-02-14 → 2013-09-12 (+210d) | baseline start 2013-02-12 → none; baseline finish 2013-02-14 → none |
| 25 | Copy reports | 2013-02-15 → 2013-09-13 (+210d) | 2013-02-19 → 2013-09-17 (+210d) | baseline start 2013-02-15 → none; baseline finish 2013-02-19 → none |
| 26 | Write cover letter | 2013-02-15 → 2013-09-13 (+210d) | 2013-02-19 → 2013-09-17 (+210d) | baseline start 2013-02-15 → none; baseline finish 2013-02-19 → none |
| 27 | **Distribute Reports** | 2013-02-19 → 2013-09-17 (+210d) | 2013-02-28 → 2013-09-26 (+210d) | baseline start 2013-02-19 → none; baseline finish 2013-02-28 → none |
| 28 | Order envelopes/paper stock | 2013-02-19 → 2013-09-17 (+210d) | 2013-02-20 → 2013-09-18 (+210d) | baseline start 2013-02-19 → none; baseline finish 2013-02-20 → none |
| 29 | Print cover letters/envelopes | 2013-02-25 → 2013-09-23 (+210d) | 2013-02-27 → 2013-09-25 (+210d) | baseline start 2013-02-25 → none; baseline finish 2013-02-27 → none |
| 30 | Stuff report packets | 2013-02-27 → 2013-09-25 (+210d) | 2013-02-28 → 2013-09-26 (+210d) | baseline start 2013-02-27 → none; baseline finish 2013-02-28 → none |
| 31 | Report packets sent | 2013-02-28 → 2013-09-26 (+210d) | 2013-02-28 → 2013-09-26 (+210d) | baseline start 2013-02-28 → none; baseline finish 2013-02-28 → none |
