# 2Template

How a schedule from MS Project changed from version to version. A marks actual dates.

## Version 1 (saved 2013-08-20, file 2template.mpp)

| ID | WBS | Task | Duration | Start | Finish | Predecessors | Complete | Total float | Constraint |
| --- | --- | --- | --- | --- | --- | --- | --- | --- | --- |
| 1 | 1 | **Shareholders Meeting** | 41d | 2008-01-02 A | 2008-02-27 |  | 58% | 0d |  |
| 2 | 1.1 | **Plan meeting** | 23.5d | 2008-01-02 A | 2008-02-04 |  | 75% | 0d |  |
| 3 | 1.1.1 | **Preliminary planning** | 23.5d | 2008-01-02 A | 2008-02-04 |  | 75% | 0d |  |
| 4 |  | Schedule conference date | 2d | 2008-01-02 A | 2008-01-03 |  | 75% | 1.5d |  |
| 5 |  | Book conference center | 2d | 2008-01-04 A | 2008-01-07 | 4 | 75% | 15d |  |
| 6 |  | Book keynote speaker | 4w | 2008-01-07 A | 2008-02-04 | 5FS-0.5d | 75% | 0d |  |
| 7 |  | Preliminary planning complete | 0d | 2008-02-04 A | 2008-02-04 | 6 | 75% | 0d |  |
| 8 | 1.2 | **Notification letter** | 9.5d | 2008-02-04 A | 2008-02-15 | 3 | 44% | 0d |  |
| 9 |  | Order letter stock | 1h | 2008-02-04 A | 2008-02-04 |  | 95% | 1.5d |  |
| 10 |  | Develop letter | 2d | 2008-02-04 A | 2008-02-06 | 9 | 75% | 2.25d |  |
| 11 |  | Review letter | 3.25d | 2008-02-06 A | 2008-02-11 | 10 | 69% | 0.62d |  |
| 12 |  | Approve letter | 1d | 2008-02-11 | 2008-02-12 | 11 |  | 0.62d |  |
| 13 |  | Print letter | 2.5d | 2008-02-12 | 2008-02-15 | 12 |  | 0.62d |  |
| 14 |  | Send letter | 0d | 2008-02-15 | 2008-02-15 | 13 |  | 0d | must finish on 2008-02-15 |
| 15 | 1.3 | **Meeting details** | 11d | 2008-02-11 A | 2008-02-26 | 3 | 43% | 1.38d |  |
| 16 |  | Plan food with caterer | 4.62d | 2008-02-11 A | 2008-02-18 | 11 | 57% | 6.75d |  |
| 17 |  | Arrange committee meeting rooms | 0.5d | 2008-02-11 A | 2008-02-12 | 16SS | 75% | 1.12d |  |
| 18 |  | Arrange necessary equipment | 1.5d | 2008-02-12 A | 2008-02-13 | 17 | 75% | 2.62d |  |
| 19 |  | Create agenda | 3.5d | 2008-02-13 A | 2008-02-19 | 18 | 75% | 0.38d |  |
| 20 |  | Print agenda | 5.5d | 2008-02-19 | 2008-02-26 | 19 |  | 0.38d |  |
| 21 |  | Meeting Details Complete | 0d | 2008-02-26 | 2008-02-26 | 20 |  | 1.38d |  |
| 22 |  | Meeting occurs! | 1d | 2008-02-27 | 2008-02-27 | 2FS+2d, 16, 17, 18, 20 |  | 0d | start no earlier than 2008-02-27 |

## Version 2 (saved 2013-09-09, file 2meeting-2013.mpp)

Last finish 2008-02-27 → 2013-07-16 (+1966d).

Changed:

| ID | Task | Start | Finish | Duration | Complete | Total float | Other |
| --- | --- | --- | --- | --- | --- | --- | --- |
| 1 | **Shareholders Meeting** | 2008-01-02 A → 2013-06-03 (+1979d) | 2008-02-27 → 2013-07-16 (+1966d) | 41d → 32d | 58% → 0% |  | baseline start 2008-01-02 → none; baseline finish 2008-02-27 → none |
| 2 | **Plan meeting** | 2008-01-02 A → 2013-06-03 (+1979d) | 2008-02-04 → 2013-06-20 (+1963d) | 23.5d → 13.5d | 75% → 0% | 0d → 1.12d | baseline start 2008-01-02 → none; baseline finish 2008-02-04 → none |
| 3 | **Preliminary planning** | 2008-01-02 A → 2013-06-03 (+1979d) | 2008-02-04 → 2013-06-20 (+1963d) | 23.5d → 13.5d | 75% → 0% | 0d → 1.12d | baseline start 2008-01-02 → none; baseline finish 2008-02-04 → none |
| 4 | Schedule conference date | 2008-01-02 A → 2013-06-03 (+1979d) | 2008-01-03 → 2013-06-04 (+1979d) |  | 75% → 0% | 1.5d → 1.12d | resources vice president; office manager → Pat Kelly; Leslie Mitchell; baseline start 2008-01-02 → none; baseline finish 2008-01-03 → none |
| 5 | Book conference center | 2008-01-04 A → 2013-06-05 (+1979d) | 2008-01-07 → 2013-06-06 (+1977d) |  | 75% → 0% | 15d → 1.12d | resources intern → Sam Merris; baseline start 2008-01-04 → none; baseline finish 2008-01-07 → none |
| 6 | Book keynote speaker | 2008-01-07 A → 2013-06-06 (+1977d) | 2008-02-04 → 2013-06-20 (+1963d) | 4w → 10d | 75% → 0% | 0d → 1.12d | resources office manager; administrative assistant → Leslie Mitchell; Terry Johnstone; baseline start 2008-01-07 → none; baseline finish 2008-02-04 → none |
| 7 | Preliminary planning complete | 2008-02-04 A → 2013-06-20 (+1963d) | 2008-02-04 → 2013-06-20 (+1963d) |  | 75% → 0% | 0d → 1.12d | baseline start 2008-02-04 → none; baseline finish 2008-02-04 → none |
| 8 | **Notification letter** | 2008-02-04 A → 2013-06-20 (+1963d) | 2008-02-15 → 2013-07-03 (+1965d) | 9.5d → 8.88d | 44% → 0% | 0d → 1.12d | baseline start 2008-02-04 → none; baseline finish 2008-02-15 → none |
| 9 | Order letter stock | 2008-02-04 A → 2013-06-20 (+1963d) | 2008-02-04 → 2013-06-20 (+1963d) |  | 95% → 0% | 1.5d → 1.12d | resources intern → Sam Merris; baseline start 2008-02-04 → none; baseline finish 2008-02-04 → none |
| 10 | Develop letter | 2008-02-04 A → 2013-06-20 (+1963d) | 2008-02-06 → 2013-06-24 (+1965d) |  | 75% → 0% | 2.25d → 1.12d | resources administrative assistant → Terry Johnstone; baseline start 2008-02-04 → none; baseline finish 2008-02-06 → none |
| 11 | Review letter | 2008-02-06 A → 2013-06-24 (+1965d) | 2008-02-11 → 2013-06-27 (+1963d) |  | 69% → 0% | 0.62d → 1.12d | resources office manager; operations manager → Leslie Mitchell; Alex Patterson; baseline start 2008-02-06 → none; baseline finish 2008-02-11 → none |
| 12 | Approve letter | 2008-02-11 → 2013-06-27 (+1963d) | 2008-02-12 → 2013-06-28 (+1963d) |  |  | 0.62d → 9.62d | resources vice president → Pat Kelly; baseline start 2008-02-11 → none; baseline finish 2008-02-12 → none |
| 13 | Print letter | 2008-02-12 → 2013-06-28 (+1963d) | 2008-02-15 → 2013-07-03 (+1965d) |  |  | 0.62d → 9.62d | resources intern [50%] → Sam Merris [50%]; baseline start 2008-02-12 → none; baseline finish 2008-02-15 → none |
| 14 | Send letter | 2008-02-15 → 2013-07-03 (+1965d) | 2008-02-15 → 2013-07-03 (+1965d) |  |  | 0d → 9.62d | constraint must finish on 2008-02-15 → none; baseline start 2008-02-15 → none; baseline finish 2008-02-15 → none |
| 15 | **Meeting details** | 2008-02-11 A → 2013-06-27 (+1963d) | 2008-02-26 → 2013-07-12 (+1963d) |  | 43% → 0% | 1.38d → 1.12d | baseline start 2008-02-11 → none; baseline finish 2008-02-26 → none |
| 16 | Plan food with caterer | 2008-02-11 A → 2013-06-27 (+1963d) | 2008-02-18 → 2013-07-04 (+1963d) |  | 57% → 0% | 6.75d → 1.12d | resources administrative assistant; office manager → Terry Johnstone; Leslie Mitchell; baseline start 2008-02-11 → none; baseline finish 2008-02-15 → none |
| 17 | Arrange committee meeting rooms | 2008-02-11 A → 2013-06-27 (+1963d) | 2008-02-12 → 2013-06-28 (+1963d) |  | 75% → 0% |  | resources intern → Sam Merris; baseline start 2008-02-11 → none; baseline finish 2008-02-12 → none |
| 18 | Arrange necessary equipment | 2008-02-12 A → 2013-06-28 (+1963d) | 2008-02-13 → 2013-07-01 (+1965d) |  | 75% → 0% | 2.62d → 1.12d | resources intern → Sam Merris; baseline start 2008-02-12 → none; baseline finish 2008-02-13 → none |
| 19 | Create agenda | 2008-02-13 A → 2013-07-01 (+1965d) | 2008-02-19 → 2013-07-05 (+1963d) |  | 75% → 0% | 0.38d → 1.12d | resources intern [50%] → Sam Merris [50%]; baseline start 2008-02-13 → none; baseline finish 2008-02-19 → none |
| 20 | Print agenda | 2008-02-19 → 2013-07-05 (+1963d) | 2008-02-26 → 2013-07-12 (+1963d) |  |  | 0.38d → 1.12d | resources intern → Sam Merris; baseline start 2008-02-19 → none; baseline finish 2008-02-26 → none |
| 21 | Meeting Details Complete | 2008-02-26 → 2013-07-12 (+1963d) | 2008-02-26 → 2013-07-12 (+1963d) |  |  | 1.38d → 2.12d | baseline start 2008-02-26 → none; baseline finish 2008-02-26 → none |
| 22 | Meeting occurs! | 2008-02-27 → 2013-07-16 (+1966d) | 2008-02-27 → 2013-07-16 (+1966d) |  |  |  | constraint start no earlier than 2008-02-27 → must finish on 2013-07-16; baseline start 2008-02-27 → none; baseline finish 2008-02-27 → none |

## Version 3 (data date 2013-07-29, saved 2013-09-16, file 5shareholder.mpp)

Last finish 2013-07-16 → 2013-07-29 (+13d). Complete tasks 0 → 1.

Added:

| ID | Task | Duration | Start | Finish | Predecessors | Resources |
| --- | --- | --- | --- | --- | --- | --- |
| 4 | Day of conference | 0d | 2013-03-12 | 2013-03-12 |  |  |
| 5 | Schedule meeting date | 1d | 2013-06-03 | 2013-06-04 | 4 | vice president; office manager |

Removed: 4 Schedule conference date; 21 Meeting Details Complete

Changed:

| ID | Task | Start | Finish | Duration | Complete | Total float | Predecessors | Other |
| --- | --- | --- | --- | --- | --- | --- | --- | --- |
| 1 | **Shareholders Meeting** | 2013-06-03 A | 2013-07-16 → 2013-07-29 (+13d) | 32d → 39.62d |  |  |  | baseline start none → 2011-06-06; baseline finish none → 2011-08-01 |
| 2 | **Plan meeting** | 2013-06-03 A | 2013-06-20 → 2013-07-24 (+34d) | 13.5d → 36.62d |  | 1.12d → 0d |  | baseline start none → 2011-06-06; baseline finish none → 2011-07-27 |
| 3 | **Preliminary planning** | 2013-06-03 A | 2013-06-20 → 2013-07-05 (+15d) | 13.5d → 24d |  | 1.12d → 0d |  | baseline start none → 2011-06-06; baseline finish none → 2011-07-08 |
| 6 | Book conference center |  | 2013-06-06 → 2013-06-10 (+4d) |  |  | 1.12d → 0d | Schedule conference date → 5 | resources Sam Merris → intern; baseline start none → 2011-06-08; baseline finish none → 2011-06-13 |
| 7 | Book keynote speaker | 2013-06-06 → 2013-06-10 (+4d) | 2013-06-20 → 2013-07-05 (+15d) |  |  | 1.12d → 0d |  | resources Leslie Mitchell; Terry Johnstone → office manager; administrative assistant; baseline start none → 2011-06-13; baseline finish none → 2011-07-08 |
| 8 | Preliminary planning complete | 2013-06-20 → 2013-07-05 A (+15d) | 2013-06-20 → 2013-07-05 A (+15d) |  | 0% → 100% | 1.12d → none |  | baseline start none → 2011-07-08; baseline finish none → 2011-07-08 |
| 9 | **Notification letter** | 2013-06-20 → 2013-07-08 (+18d) | 2013-07-03 → 2013-07-18 (+15d) | 8.88d → 7.62d |  | 1.12d → 0d |  | baseline start none → 2011-07-11; baseline finish none → 2011-07-21 |
| 10 | Order letter stock | 2013-06-20 → 2013-07-08 (+18d) | 2013-06-20 → 2013-07-08 (+18d) |  |  | 1.12d → 0d |  | resources Sam Merris → intern; baseline start none → 2011-07-11; baseline finish none → 2011-07-11 |
| 11 | Develop letter | 2013-06-20 → 2013-07-08 (+18d) | 2013-06-24 → 2013-07-10 (+16d) | 2d → 1d |  | 1.12d → 0d |  | resources Terry Johnstone → administrative assistant; baseline start none → 2011-07-11; baseline finish none → 2011-07-13 |
| 12 | Review letter | 2013-06-24 → 2013-07-08 (+14d) | 2013-06-27 → 2013-07-10 (+13d) | 3.25d → 1d |  | 1.12d → 0d | 11 → 11SS | resources Leslie Mitchell; Alex Patterson → office manager; operations manager; baseline start none → 2011-07-11; baseline finish none → 2011-07-13 |
| 13 | Approve letter | 2013-06-27 → 2013-07-10 (+13d) | 2013-06-28 → 2013-07-12 (+14d) |  |  | 9.62d → 4d |  | resources Pat Kelly → vice president; baseline start none → 2011-07-13; baseline finish none → 2011-07-15 |
| 14 | Print letter | 2013-06-28 → 2013-07-12 (+14d) | 2013-07-03 → 2013-07-18 (+15d) | 2.5d → 2d |  | 9.62d → 4d |  | resources Sam Merris [50%] → intern [50%]; baseline start none → 2011-07-15; baseline finish none → 2011-07-21 |
| 15 | Send letter | 2013-07-03 → 2013-07-18 (+15d) | 2013-07-03 → 2013-07-18 (+15d) |  |  | 9.62d → 4d |  | baseline start none → 2011-07-21; baseline finish none → 2011-07-21 |
| 16 | **Meeting details** | 2013-06-27 → 2013-07-10 (+13d) | 2013-07-12 → 2013-07-24 (+12d) | 11d → 10d |  | 1.12d → 0d |  | baseline start none → 2011-07-13; baseline finish none → 2011-07-27 |
| 17 | Plan food with caterer | 2013-06-27 → 2013-07-10 (+13d) | 2013-07-04 → 2013-07-18 (+14d) | 4.62d → 3d |  | 1.12d → 0d |  | resources Terry Johnstone; Leslie Mitchell → administrative assistant; office manager; baseline start none → 2011-07-13; baseline finish none → 2011-07-21 |
| 18 | Arrange committee meeting rooms | 2013-06-27 → 2013-07-10 (+13d) | 2013-06-28 → 2013-07-11 (+13d) |  |  | 1.12d → 0d |  | resources Sam Merris → intern; baseline start none → 2011-07-13; baseline finish none → 2011-07-14 |
| 19 | Arrange necessary equipment | 2013-06-28 → 2013-07-11 (+13d) | 2013-07-01 → 2013-07-12 (+11d) | 1.5d → 0.5d |  | 1.12d → 0d |  | resources Sam Merris → intern; baseline start none → 2011-07-14; baseline finish none → 2011-07-15 |
| 20 | Create agenda | 2013-07-01 → 2013-07-12 (+11d) | 2013-07-05 → 2013-07-22 (+17d) | 3.5d → 3d |  | 1.12d → 0d |  | resources Sam Merris [50%] → intern [50%]; baseline start none → 2011-07-15; baseline finish none → 2011-07-25 |
| 21 | Print agenda | 2013-07-05 → 2013-07-22 (+17d) | 2013-07-12 → 2013-07-24 (+12d) | 5.5d → 1d |  | 1.12d → 0d |  | resources Sam Merris → intern; baseline start none → 2011-07-25; baseline finish none → 2011-07-27 |
| 22 | Meeting occurs! | 2013-07-16 → 2013-07-26 (+10d) | 2013-07-16 → 2013-07-29 (+13d) |  |  |  |  | constraint must finish on 2013-07-16 → none; baseline start none → 2011-07-29; baseline finish none → 2011-08-01 |

## Version 4 (data date 2013-05-24, saved 2013-10-01, file 6share2.mpp)

Last finish 2013-07-29 → 2013-06-12 (-47d).

Removed: 4 Day of conference

Changed:

| ID | Task | Start | Finish | Duration | Total float | Predecessors | Other |
| --- | --- | --- | --- | --- | --- | --- | --- |
| 1 | **Shareholders Meeting** | 2013-06-03 A → 2013-05-14 A (-20d) | 2013-07-29 → 2013-06-12 (-47d) | 39.62d → 21.62d |  |  | baseline start 2011-06-06 → 2013-05-14; baseline finish 2011-08-01 → 2013-06-12 |
| 2 | **Plan meeting** | 2013-06-03 A → 2013-05-14 A (-20d) | 2013-07-24 → 2013-06-07 (-47d) | 36.62d → 18.62d |  |  | baseline start 2011-06-06 → 2013-05-14; baseline finish 2011-07-27 → 2013-06-07 |
| 3 | **Preliminary planning** | 2013-06-03 A → 2013-05-14 A (-20d) | 2013-07-05 → 2013-05-30 (-36d) | 24d → 12.5d |  |  | baseline start 2011-06-06 → 2013-05-14; baseline finish 2011-07-08 → 2013-05-30 |
| 4 | Schedule meeting date | 2013-06-03 → 2013-05-14 (-20d) | 2013-06-04 → 2013-05-14 (-21d) |  |  | Day of conference → none | resources vice president; office manager → none; baseline start 2011-06-06 → 2013-05-14; baseline finish 2011-06-07 → 2013-05-14 |
| 5 | Book conference center | 2013-06-05 → 2013-05-15 (-21d) | 2013-06-10 → 2013-05-16 (-25d) |  |  |  | resources intern → none; baseline start 2011-06-08 → 2013-05-15; baseline finish 2011-06-13 → 2013-05-16 |
| 6 | Book keynote speaker | 2013-06-10 → 2013-05-16 (-25d) | 2013-07-05 → 2013-05-30 (-36d) |  |  |  | resources office manager; administrative assistant → none; baseline start 2011-06-13 → 2013-05-16; baseline finish 2011-07-08 → 2013-05-30 |
| 7 | Preliminary planning complete | 2013-07-05 A → 2013-05-30 A (-36d) | 2013-07-05 A → 2013-05-30 A (-36d) |  |  |  | baseline start 2011-07-08 → 2013-05-30; baseline finish 2011-07-08 → 2013-05-30 |
| 8 | **Notification letter** | 2013-07-08 → 2013-05-30 (-39d) | 2013-07-18 → 2013-06-05 (-43d) | 7.62d → 4.12d |  |  | baseline start 2011-07-11 → 2013-05-30; baseline finish 2011-07-21 → 2013-06-05 |
| 9 | Order letter stock | 2013-07-08 → 2013-05-30 (-39d) | 2013-07-08 → 2013-05-30 (-39d) |  |  |  | resources intern → none; baseline start 2011-07-11 → 2013-05-30; baseline finish 2011-07-11 → 2013-05-30 |
| 10 | Develop letter | 2013-07-08 → 2013-05-30 (-39d) | 2013-07-10 → 2013-05-31 (-40d) |  |  |  | resources administrative assistant → none; baseline start 2011-07-11 → 2013-05-30; baseline finish 2011-07-13 → 2013-05-31 |
| 11 | Review letter | 2013-07-08 → 2013-05-30 (-39d) | 2013-07-10 → 2013-05-31 (-40d) |  |  |  | resources office manager; operations manager → none; baseline start 2011-07-11 → 2013-05-30; baseline finish 2011-07-13 → 2013-05-31 |
| 12 | Approve letter | 2013-07-10 → 2013-05-31 (-40d) | 2013-07-12 → 2013-06-03 (-39d) |  | 4d → 2d |  | resources vice president → none; baseline start 2011-07-13 → 2013-05-31; baseline finish 2011-07-15 → 2013-06-03 |
| 13 | Print letter | 2013-07-12 → 2013-06-03 (-39d) | 2013-07-18 → 2013-06-05 (-43d) |  | 4d → 2d |  | resources intern [50%] → none; baseline start 2011-07-15 → 2013-06-03; baseline finish 2011-07-21 → 2013-06-05 |
| 14 | Send letter | 2013-07-18 → 2013-06-05 (-43d) | 2013-07-18 → 2013-06-05 (-43d) |  | 4d → 2d |  | baseline start 2011-07-21 → 2013-06-05; baseline finish 2011-07-21 → 2013-06-05 |
| 15 | **Meeting details** | 2013-07-10 → 2013-05-31 (-40d) | 2013-07-24 → 2013-06-07 (-47d) | 10d → 5d |  |  | baseline start 2011-07-13 → 2013-05-31; baseline finish 2011-07-27 → 2013-06-07 |
| 16 | Plan food with caterer | 2013-07-10 → 2013-05-31 (-40d) | 2013-07-18 → 2013-06-05 (-43d) |  |  |  | resources administrative assistant; office manager → none; baseline start 2011-07-13 → 2013-05-31; baseline finish 2011-07-21 → 2013-06-05 |
| 17 | Arrange committee meeting rooms | 2013-07-10 → 2013-05-31 (-40d) | 2013-07-11 → 2013-06-03 (-38d) |  |  |  | resources intern → none; baseline start 2011-07-13 → 2013-05-31; baseline finish 2011-07-14 → 2013-06-03 |
| 18 | Arrange necessary equipment | 2013-07-11 → 2013-06-03 (-38d) | 2013-07-12 → 2013-06-03 (-39d) |  |  |  | resources intern → none; baseline start 2011-07-14 → 2013-06-03; baseline finish 2011-07-15 → 2013-06-03 |
| 19 | Create agenda | 2013-07-12 → 2013-06-03 (-39d) | 2013-07-22 → 2013-06-06 (-46d) |  |  |  | resources intern [50%] → none; baseline start 2011-07-15 → 2013-06-03; baseline finish 2011-07-25 → 2013-06-06 |
| 20 | Print agenda | 2013-07-22 → 2013-06-06 (-46d) | 2013-07-24 → 2013-06-07 (-47d) |  |  |  | resources intern → none; baseline start 2011-07-25 → 2013-06-06; baseline finish 2011-07-27 → 2013-06-07 |
| 21 | Meeting occurs! | 2013-07-26 → 2013-06-11 (-45d) | 2013-07-29 → 2013-06-12 (-47d) |  |  |  | baseline start 2011-07-29 → 2013-06-11; baseline finish 2011-08-01 → 2013-06-12 |
